# ProjectPlanASIC1.1detailed

Schedule from MS Project, 2008-05-01 to 2008-07-14, 7.5 hours a day.
CCLRC

## Calendars

- Standard: Mon-Fri 08:30-12:00, 13:00-17:00; Sat-Sun off. Exceptions (off unless hours are given): 2008-05-02, 2008-06-25 to 2008-06-27, 2008-06-30.

## Schedule

| ID | WBS | Task | Type | Duration | Start | Finish | Predecessors | Total slack | Free slack | Constraint |
| --- | --- | --- | --- | --- | --- | --- | --- | --- | --- | --- |
| 1 | 1 | Preliminary design review | milestone | 3h | 2008-05-01 | 2008-05-01 |  | 30.4d |  |  |
| 2 | 2 | **Bug fix 3 (level-shift logic)** |  | 10d | 2008-05-01 | 2008-05-15 |  | 17.5d | 0d |  |
| 3 | 2.1 | Schematic design |  | 0.5d | 2008-05-01 | 2008-05-01 |  | 17.5d | 0d |  |
| 4 | 2.2 | Simulation verification |  | 3d | 2008-05-01 | 2008-05-07 | 3 | 17.5d | 0d |  |
| 5 | 2.3 | Layout of new circuits |  | 1d | 2008-05-07 | 2008-05-08 | 4 | 17.5d | 0d |  |
| 6 | 2.4 | Insert into existing logic layout |  | 2d | 2008-05-08 | 2008-05-12 | 5 | 17.5d | 0d |  |
| 7 | 2.5 | DRC full logic block |  | 1.5d | 2008-05-12 | 2008-05-13 | 6 | 17.5d | 0d |  |
| 8 | 2.6 | LVS full logic block |  | 2d | 2008-05-14 | 2008-05-15 | 7 | 17.5d |  |  |
| 9 | 3 | **Bug fix 1&2 (biases)** |  | 1d | 2008-05-16 | 2008-05-16 | 2 | 17.5d | 0d |  |
| 10 | 3.1 | Schematic & simulation |  | 3h | 2008-05-16 | 2008-05-16 |  | 17.5d | 0d |  |
| 11 | 3.2 | Layout |  | 4.5h | 2008-05-16 | 2008-05-16 | 10 | 17.5d |  |  |
| 12 | 4 | **Change preSample pixels to preShape** |  | 5d | 2008-05-19 | 2008-05-23 | 9 | 17.5d | 0d |  |
| 13 | 4.1 | Schematic changes |  | 1d | 2008-05-19 | 2008-05-19 |  | 17.5d | 0d |  |
| 14 | 4.2 | Layout changes |  | 1d | 2008-05-20 | 2008-05-20 | 13 | 17.5d | 0d |  |
| 15 | 4.3 | DRC |  | 1d | 2008-05-21 | 2008-05-21 | 14 | 17.5d | 0d |  |
| 16 | 4.4 | LVS |  | 2d | 2008-05-22 | 2008-05-23 | 15 | 17.5d |  |  |
| 17 | 5 | **Change test structures to preShape** |  | 6d | 2008-05-26 | 2008-06-02 | 12 | 17.5d | 0d |  |
| 18 | 5.1 | Schematics |  | 1d | 2008-05-26 | 2008-05-26 |  | 17.5d | 0d |  |
| 19 | 5.2 | Layout |  | 2d | 2008-05-27 | 2008-05-28 | 18 | 17.5d | 0d |  |
| 20 | 5.3 | LVS |  | 1d | 2008-05-29 | 2008-05-29 | 19 | 17.5d | 0d |  |
| 21 | 5.4 | Integrate layout with top level |  | 2d | 2008-05-30 | 2008-06-02 | 20 | 17.5d |  |  |
| 22 | 6 | **Feasability study: Extra Trim bits** |  | 16d | 2008-05-08 | 2008-05-29 |  | 19.5d | 6d |  |
| 23 | 6.1 | Layout feasability |  | 2d | 2008-05-08 | 2008-05-09 |  | 19.5d | 0d | start no earlier than 2008-05-08 |
| 24 | 6.2 | Layout changes |  | 2w | 2008-05-12 | 2008-05-23 | 23 | 19.5d | 0d |  |
| 25 | 6.3 | DRC |  | 1d | 2008-05-26 | 2008-05-26 | 24 | 19.5d | 0d |  |
| 26 | 6.4 | LVS |  | 3d | 2008-05-27 | 2008-05-29 | 25 | 19.5d |  |  |

| ID | WBS | Task | Type | Duration | Start | Finish | Predecessors | Total slack | Free slack | Constraint |
| --- | --- | --- | --- | --- | --- | --- | --- | --- | --- | --- |
| 27 | 7 | **Top Level Checks** |  | 8.5d | 2008-06-03 | 2008-06-13 | 22, 17 | 17.5d |  |  |
| 28 | 7.1 | Integrate new pixel layout |  | 2d | 2008-06-03 | 2008-06-04 |  | 17.5d | 0d |  |
| 29 | 7.2 | DRC |  | 2d | 2008-06-05 | 2008-06-06 | 28 | 17.5d | 0d |  |
| 30 | 7.3 | LVS |  | 3d | 2008-06-09 | 2008-06-11 | 29 | 17.5d | 0d |  |
| 31 | 7.4 | Antennas |  | 0.5d | 2008-06-12 | 2008-06-12 | 30 | 17.5d | 0d |  |
| 32 | 7.5 | Regenerate fill |  | 1d | 2008-06-12 | 2008-06-13 | 31 | 17.5d |  |  |
| 33 | 8 | FDR | milestone | 6h | 2008-06-13 | 2008-06-13 |  | 1.2d | 0d | start no earlier than 2008-06-13 |
| 34 | 9 | Contingency & Final checks/changes |  | 3w | 2008-06-13 | 2008-07-10 | 33 | 1.2d |  |  |
| 35 | 10 | MPW Submission deadline | milestone | 1d | 2008-07-14 | 2008-07-14 | 34 | 0d |  | start no earlier than 2008-07-14 |
